# ГПР ЖД

Schedule from MS Project, 2025-09-01 to 2026-02-20.

## Calendars

- Стандартный: Mon-Fri 09:00-13:00, 14:00-18:00; Sat-Sun off.

## Schedule

| ID | WBS | Task | Duration | Start | Finish | Predecessors | Total slack | Free slack |
| --- | --- | --- | --- | --- | --- | --- | --- | --- |
| 1 | 1 | **Переустройство ж/д инфраструктуры терминала по перевалке минеральных удобрений** | 125d | 2025-09-01 | 2026-02-20 |  | 0d |  |
| 2 | 1.1 | Подготовка площадки | 5d | 2025-09-01 | 2025-09-05 |  | 0d |  |
| 3 | 1.2 | Организация площадки, подвоз оборудования | 5d | 2025-09-08 | 2025-09-12 | 2 | 0d |  |
| 4 | 1.3 | Демонтаж рельсов пути №2–7 | 15d | 2025-09-15 | 2025-10-03 | 3 | 0d |  |
| 5 | 1.4 | Демонтаж шпал пути №2–7 | 15d | 2025-09-15 | 2025-10-03 | 4SS | 100d |  |
| 6 | 1.5 | Демонтаж рельсов пути №1 | 5d | 2025-09-15 | 2025-09-19 | 3 | 110d |  |
| 7 | 1.6 | Демонтаж шпал пути №1 | 5d | 2025-09-15 | 2025-09-19 | 3 | 110d |  |
| 8 | 1.7 | Переустройство инженерных сетей | 15d | 2025-09-15 | 2025-10-03 | 3 | 100d |  |
| 9 | 1.8 | Устройство земляного полотна | 15d | 2025-10-06 | 2025-10-24 | 4 | 0d |  |
| 10 | 1.9 | Укладка геотекстиля | 15d | 2025-10-06 | 2025-10-24 | 4 | 85d |  |
| 11 | 1.10 | Устройство балластной призмы | 10d | 2025-10-15 | 2025-10-28 | 9SS+7d | 0d |  |
| 12 | 1.11 | Доставка ЖБ шпал и стрелочного бруса | 10d | 2025-10-22 | 2025-11-04 | 11SS+5d | 0d |  |
| 13 | 1.12 | Разгрузка и раскладка шпал | 5d | 2025-11-05 | 2025-11-11 | 12 | 0d |  |
| 14 | 1.13 | Оснащение шпал скреплениями | 7d | 2025-11-12 | 2025-11-20 | 13 | 0d |  |
| 15 | 1.14 | Раскладка рельсов вручную | 7d | 2025-11-21 | 2025-12-01 | 14 | 0d |  |
| 16 | 1.15 | Позиционирование и выравнивание | 7d | 2025-12-02 | 2025-12-10 | 15 | 0d |  |
| 17 | 1.16 | Сборка стрелочной улицы | 30d | 2025-12-11 | 2026-01-21 | 16 | 8d | 0d |
| 18 | 1.17 | Финальная проверка и корректировка | 10d | 2026-01-22 | 2026-02-04 | 17 | 12d |  |
| 19 | 1.18 | Балластировка | 45d | 2025-12-02 | 2026-02-02 | 16SS, 17FF | 0d |  |
| 20 | 1.19 | Выправка в плане и профиле | 45d | 2025-12-02 | 2026-02-02 | 19SS | 0d |  |
| 21 | 1.20 | Сдача и оформление документации | 14d | 2026-02-03 | 2026-02-20 | 20 | 0d |  |
